# Cronograma Inicial_PND_V4_Datacenter_IaaS

Schedule from MS Project, 2021-03-15 to 2021-06-22.

## Calendars

- ANH: Mon-Fri 09:00-13:00, 15:00-19:00; Sat-Sun off.

## Resources

| Resource | Group |
| --- | --- |
| Hernan Morales | Lideres |
| Oswaldo Alvarado | lideres |
| Claudia Acosta | lideres |
| Esperanza Charry | Consultores |
| Milton Barrera | Consultores |
| Jeffer Cardenas | Consultores |
| Johan Cruz | Consultores |
| ANH |  |
| Wilfredo Lopez |  |
| ANderson Cadavid |  |
| John Pardo |  |
| Hugo Vargas |  |

## Schedule

| ID | WBS | Task | Type | Duration | Start | Finish | Predecessors | Total slack | Free slack | Constraint |
| --- | --- | --- | --- | --- | --- | --- | --- | --- | --- | --- |
| 1 | 1 | **FND** |  | 71.25d | 2021-03-15 09:00 | 2021-06-22 11:00 |  | 0d |  |  |
| 2 | 1.1 | **Proyecto Migración Servicios Definición E Implementación** |  | 9.75d | 2021-03-15 09:00 | 2021-03-26 17:00 |  | 0d |  |  |
| 3 | 1.1.1 | **Inicio** |  | 0d | 2021-03-15 09:00 | 2021-03-15 09:00 |  | 0d |  |  |
| 4 | 1.1.1.1 | KickOff | milestone, manual | 0d | 2021-03-15 09:00 | 2021-03-15 09:00 |  |  |  |  |
| 5 | 1.1.1.2 | Acta de Inicio | milestone | 0d | 2021-03-15 09:00 | 2021-03-15 09:00 | 4 | 0d |  | start no earlier than 2021-03-15 09:00 |
| 6 | 1.1.2 | **Planeación** |  | 5d | 2021-03-15 09:00 | 2021-03-19 19:00 | 4 | 0d |  |  |
| 7 | 1.1.2.1 | **Generación Plan de Entrevistas** |  | 2.38d | 2021-03-15 09:00 | 2021-03-17 12:00 | 5 | 68.88d |  |  |
| 8 | 1.1.2.1.1 | Seleccionar grupo de funcionarios a entrevistar |  | 3h | 2021-03-15 09:00 | 2021-03-15 12:00 | 5 | 68.88d | 0d | start no earlier than 2020-10-06 09:00 |
| 9 | 1.1.2.1.2 | Realizar agendamiento del equipo |  | 2d | 2021-03-15 12:00 | 2021-03-17 12:00 | 8 | 68.88d |  |  |
| 10 | 1.1.2.2 | **Levantamiento de Información General** |  | 5d | 2021-03-15 09:00 | 2021-03-19 19:00 | 4 | 0d |  |  |
| 11 | 1.1.2.2.1 | **Conocimiento de la Entidad (Recepción Documentación)** |  | 5d | 2021-03-15 09:00 | 2021-03-19 19:00 | 4 | 0d |  |  |
| 12 | 1.1.2.2.1.1 | Mapa y caracterización de procesos que rige actualmente en la entidad - asegurado con el área de Planeación |  | 8h | 2021-03-15 09:00 | 2021-03-15 19:00 | 5 | 0d |  | start no earlier than 2020-10-05 09:00 |
| 13 | 1.1.2.2.1.2 | Manual de Calidad aprobado y que rige actualmente en la entidad |  | 8h | 2021-03-16 09:00 | 2021-03-16 19:00 | 12 | 69.25d |  |  |
| 14 | 1.1.2.2.1.3 | Modelo de formatos para documentación acorde con los estándares de calidad de FND |  | 4h | 2021-03-16 09:00 | 2021-03-16 13:00 | 12 | 69.75d |  | start no earlier than 2020-10-05 09:00 |
| 15 | 1.1.2.2.1.4 | Metodología de Evaluación y Tratamiento de Riesgos |  | 4h | 2021-03-16 09:00 | 2021-03-16 13:00 | 12 | 69.75d |  | start no earlier than 2020-10-05 09:00 |
| 16 | 1.1.2.2.1.5 | Plan estratégico institucional –PEI |  | 2h | 2021-03-16 09:00 | 2021-03-16 11:00 | 12 | 70d |  | start no earlier than 2020-10-05 09:00 |
| 17 | 1.1.2.2.1.6 | Indicar los objetivos estratégicos de la entidad |  | 4h | 2021-03-16 09:00 | 2021-03-16 13:00 | 12 | 69.75d |  | start no earlier than 2020-10-05 09:00 |
| 18 | 1.1.2.2.1.7 | Definición de los Procesos Críticos a los cuales se les aplicará el Análisis de Impacto |  | 4d | 2021-03-16 09:00 | 2021-03-19 19:00 | 12 | 66.25d |  | start no earlier than 2020-10-05 09:00 |
| 19 | 1.1.2.2.1.8 | Suministrar la documentación arquitectura actual en HCI, aplicaciones, interdependencias, SO,herramientas y utilitarios claves, topología, mecanismos y procedimientos de replicación |  | 4h | 2021-03-16 09:00 | 2021-03-16 13:00 | 12 | 69.75d |  | start no earlier than 2020-10-05 09:00 |
| 20 | 1.1.2.2.1.9 | Suministrar un repositorio para unificar y consolidar la información en la intranet de FND |  | 4h | 2021-03-16 09:00 | 2021-03-16 13:00 | 12 | 69.75d |  | start no earlier than 2020-10-05 09:00 |
| 21 | 1.1.2.2.1.10 | Suministrar una o varias cuentas para el equipo de consultoría, para asegurar el intercambio de información entre personal de FND y equipo de consultores y gerente de proyecto, según las políticas de la PND. |  | 4h | 2021-03-16 09:00 | 2021-03-16 13:00 | 12 | 0d |  | start no earlier than 2020-10-05 09:00 |
| 22 | 1.1.2.2.2 | Visita Data Centers |  | 1d | 2021-03-16 15:00 | 2021-03-17 13:00 | 21 | 2.38d | 0d | start no earlier than 2020-10-15 09:00 |
| 23 | 1.1.3 | **Ejecución** |  | 4.25d | 2021-03-16 15:00 | 2021-03-22 17:00 |  | 0d |  |  |
| 24 | 1.1.3.1 | **Definición de Migracion** |  | 4.25d | 2021-03-16 15:00 | 2021-03-22 17:00 |  | 0d |  |  |
| 25 | 1.1.3.1.1 | **Revisión del Contexto de la organización base** |  | 1d | 2021-03-16 15:00 | 2021-03-17 13:00 |  | 3.25d |  |  |
| 26 | 1.1.3.1.1.1 | Entender la organización FND y su contexto |  | 4h | 2021-03-16 15:00 | 2021-03-16 19:00 | 21 | 3.25d | 0d |  |
| 27 | 1.1.3.1.1.2 | Revisar las referencia normativas |  | 4h | 2021-03-17 09:00 | 2021-03-17 13:00 | 26 | 3.25d |  |  |

| ID | WBS | Task | Duration | Start | Finish | Predecessors | Total slack | Free slack |
| --- | --- | --- | --- | --- | --- | --- | --- | --- |
| 28 | 1.1.3.1.2 | **Revisión del Liderazgo respecto a migracion** | 0.5d | 2021-03-16 15:00 | 2021-03-16 19:00 |  | 0d |  |
| 29 | 1.1.3.1.2.1 | Determinar Liderazgo y Compromiso | 2h | 2021-03-16 15:00 | 2021-03-16 17:00 | 21 | 0d |  |
| 30 | 1.1.3.1.2.2 | Definir la Política | 2h | 2021-03-16 17:00 | 2021-03-16 19:00 | 29 | 0d |  |
| 31 | 1.1.3.1.3 | **Revisión de Planeación** | 0.5d | 2021-03-16 15:00 | 2021-03-16 19:00 |  | 1.5d |  |
| 32 | 1.1.3.1.3.1 | Determinar Acciones para abordar riesgos y oportunidades | 4h | 2021-03-16 15:00 | 2021-03-16 19:00 | 21 | 1.5d |  |
| 33 | 1.1.3.1.4 | **Revisión y diseño del Soporte** | 2d | 2021-03-16 15:00 | 2021-03-18 13:00 |  | 0d |  |
| 34 | 1.1.3.1.4.1 | Determinar los recursos | 4h | 2021-03-17 09:00 | 2021-03-17 13:00 | 28 | 0d |  |
| 35 | 1.1.3.1.4.2 | Determinar las competencias | 4h | 2021-03-17 15:00 | 2021-03-17 19:00 | 34 | 0d |  |
| 36 | 1.1.3.1.4.3 | Determinar necesidades de conocimiento y concientiación | 4h | 2021-03-18 09:00 | 2021-03-18 13:00 | 35 | 0d |  |
| 37 | 1.1.3.1.4.4 | Determinar el plan de comunicación | 4h | 2021-03-16 15:00 | 2021-03-16 19:00 | 21 | 1d | 0d |
| 38 | 1.1.3.1.4.5 | Determinar la Información documentada | 4h | 2021-03-17 09:00 | 2021-03-17 13:00 | 37 | 1d |  |
| 39 | 1.1.3.1.5 | **Revisión y diseño de la Operación** | 1.25d | 2021-03-18 15:00 | 2021-03-19 17:00 |  | 0d |  |
| 40 | 1.1.3.1.5.1 | Definir la planeación y Control Operacional | 4h | 2021-03-18 15:00 | 2021-03-18 19:00 | 31, 33 | 1.75d |  |
| 41 | 1.1.3.1.5.2 | Análizar el Impacto al Negocio y Evaluar los Riesgos | 4h | 2021-03-18 15:00 | 2021-03-18 19:00 | 31, 33 | 0d |  |
| 42 | 1.1.3.1.5.3 | Definir las estrategias para la continuidad de Negocio y Soluciones | 2h | 2021-03-19 09:00 | 2021-03-19 11:00 | 41 | 0d |  |
| 43 | 1.1.3.1.5.4 | Definir los planes y procedimientos para la continuidad de negocio | 2h | 2021-03-19 11:00 | 2021-03-19 13:00 | 42 | 0d |  |
| 44 | 1.1.3.1.5.5 | Definir el plan de ejercicios (prueba de escritorio y prueba funcional en ambiente controlado) | 2h | 2021-03-19 15:00 | 2021-03-19 17:00 | 43 | 0d |  |
| 45 | 1.1.3.1.5.6 | Definir el procedimiento de evaluación de la documentación y capacidad de continuidad de negocio. | 2h | 2021-03-19 09:00 | 2021-03-19 11:00 | 41 | 1.5d |  |
| 46 | 1.1.3.1.6 | **Revisión y diseño de la Evaluación del desempeño** | 1.25d | 2021-03-19 15:00 | 2021-03-22 17:00 |  | 0d |  |
| 47 | 1.1.3.1.6.1 | Definir el monitoreo, medición, análisis y evaluación | 4h | 2021-03-19 15:00 | 2021-03-19 19:00 | 43 | 0.75d |  |
| 48 | 1.1.3.1.6.2 | Definir el procedimiento de Auditoria Interna | 4h | 2021-03-19 17:00 | 2021-03-22 11:00 | 44 | 0d |  |
| 49 | 1.1.3.1.6.3 | Definir el procedimiento de Gestión por parte de la Alta Dirección | 4h | 2021-03-22 11:00 | 2021-03-22 17:00 | 48 | 0d |  |
| 50 | 1.1.3.2 | **Revisión Políticas de Seguridad** | 0.88d | 2021-03-17 15:00 | 2021-03-18 12:00 |  | 2.38d |  |
| 51 | 1.1.3.2.1 | Levantamiento de politicas de Seguridad de la opeación | 5h | 2021-03-17 15:00 | 2021-03-18 10:00 | 22 | 2.38d | 0d |
| 52 | 1.1.3.2.2 | Validacion de esquemas de migración | 2h | 2021-03-18 10:00 | 2021-03-18 12:00 | 51 | 2.38d |  |

| ID | WBS | Task | Duration | Start | Finish | Predecessors | Total slack | Constraint |
| --- | --- | --- | --- | --- | --- | --- | --- | --- |
| 53 | 1.1.4 | **Cierre** | 4d | 2021-03-22 17:00 | 2021-03-26 17:00 |  | 61.5d |  |
| 54 | 1.1.4.1 | **Entregables del Proyecto** | 4d | 2021-03-22 17:00 | 2021-03-26 17:00 |  | 61.5d |  |
| 55 | 1.1.4.1.1 | **Migración** | 4d | 2021-03-22 17:00 | 2021-03-26 17:00 |  | 61.5d |  |
| 56 | 1.1.4.1.1.1 | Consolidación Informacion de la migración | 4d | 2021-03-22 17:00 | 2021-03-26 17:00 | 24, 50 | 61.5d |  |
| 57 | 1.2 | **Migración a nuevo Datacenter** | 45.25d | 2021-03-22 17:00 | 2021-05-24 19:00 |  | 0d |  |
| 58 | 1.2.1 | **Descripción Servicio: Tareas Iniciales de Traslado:** | 3d | 2021-03-22 17:00 | 2021-03-25 17:00 |  | 0d |  |
| 59 | 1.2.1.1 | Reunión Inicio y Kickoff. | 8h | 2021-03-22 17:00 | 2021-03-23 17:00 | 24, 50 | 64.5d | start no earlier than 2020-10-13 09:00 |
| 60 | 1.2.1.2 | Reuniones de entendimiento del proyecto. | 24h | 2021-03-22 17:00 | 2021-03-25 17:00 | 24, 50 | 0d | start no earlier than 2020-10-13 09:00 |
| 61 | 1.2.2 | **Verificar Requerimientos para el Traslado:** | 2.12d | 2021-03-25 17:00 | 2021-03-29 18:00 |  | 0d |  |
| 62 | 1.2.2.1 | Elaboración y Verificación de Inventario de Equipos a trasladar. | 8h | 2021-03-25 17:00 | 2021-03-26 17:00 | 60 | 0d |  |
| 63 | 1.2.2.2 | Levantamiento de Información de Equipos a trasladar. | 8h | 2021-03-26 17:00 | 2021-03-29 17:00 | 62 | 0d |  |
| 64 | 1.2.2.3 | **Site Survey** | 0.12d | 2021-03-29 17:00 | 2021-03-29 18:00 | 63 | 0d |  |
| 65 | 1.2.2.3.1 | Ejecución del site survey en el centro de datos de destino con el objetivo de identificar problemas en el montaje y conexión de los equipos. | 1h | 2021-03-29 17:00 | 2021-03-29 18:00 | 63 | 0d |  |
| 66 | 1.2.3 | **Actividades de Inicio de Ejecución de Migracion** | 30.62d | 2021-03-29 18:00 | 2021-05-11 13:00 |  | 0d |  |
| 67 | 1.2.3.1 | Acompañamiento de Especialistas en Copias de seguridad de los datos: Elaboración de un plan de recuperación de datos que haya sido probado mediante prácticas de arranque a intervalos regulares durante la fase de planificación. Las herramientas de virtuali | 2h | 2021-03-29 18:00 | 2021-03-30 10:00 | 65 | 0d |  |
| 68 | 1.2.3.2 | Acompañamiento de Especialistas en la implementación de las estrategias de Continuidad del Servicio definidas en el Plan de traslado. | 3h | 2021-03-30 10:00 | 2021-03-30 13:00 | 67 | 0d |  |
| 69 | 1.2.3.3 | Movimiento de las maquinas y reintalacion de SO, Estas labores se deben coordinas con la entidad para poder determinar las mejores fechas conforme a su operación y sus recursos internos (ESTOS TIEMPOS DEPENDEN DE LOS PROCESOS INTERNOS DE PND PARA APROBACI | 30d | 2021-03-30 15:00 | 2021-05-11 13:00 | 68 | 0d |  |
| 70 | 1.2.4 | **Labores Post Configuración** | 9.5d | 2021-05-11 15:00 | 2021-05-24 19:00 |  | 0d |  |
| 71 | 1.2.4.1 | Documentación final del proyecto de Traslado, Repositorio de los activos, esquemas de interconexión, diagramas de red, entregables de proyecto que incluyen: - Asignación recursos por parte del proveedor de traslado. - Levantamiento fotográfico estado actu | 76h | 2021-05-11 15:00 | 2021-05-24 19:00 | 69 | 0d |  |
| 72 | 1.3 | **Proyecto Administración, Monitoreo y Gestión de los Datacenter de la Entidad** | 20.25d | 2021-05-25 09:00 | 2021-06-22 11:00 |  | 0d |  |
| 73 | 1.3.1 | **Levantamiento de Informacion** | 1d | 2021-05-25 09:00 | 2021-05-25 19:00 | 71 | 19.25d |  |
| 74 | 1.3.1.1 | Reuniones para levantamiento de informacion de cada una de las plataformas a gestiona | 1d | 2021-05-25 09:00 | 2021-05-25 19:00 |  | 19.25d |  |
| 75 | 1.3.2 | **Fase de Transicion** | 5.25d | 2021-05-25 09:00 | 2021-06-01 11:00 | 71 | 0d |  |
| 76 | 1.3.2.1 | Planificación y Soporte de la Transición | 10h | 2021-05-25 09:00 | 2021-05-26 11:00 |  | 0d | start no earlier than 2020-10-09 09:00 |
| 77 | 1.3.2.2 | Establecer proceso de Gestión del Cambio | 1d | 2021-05-26 11:00 | 2021-05-27 11:00 | 76 | 0d |  |
| 78 | 1.3.2.3 | Establecer proceso de Gestión de la Configuración y Activos | 1d | 2021-05-27 11:00 | 2021-05-28 11:00 | 77 | 0d |  |
| 79 | 1.3.2.4 | Establecer proceso de Gestión de Entregas y Despliegues | 1d | 2021-05-28 11:00 | 2021-05-31 11:00 | 78 | 0d |  |
| 80 | 1.3.2.5 | Entregas por Servicio | 1d | 2021-05-31 11:00 | 2021-06-01 11:00 | 79 | 0d |  |
| 81 | 1.3.3 | Periodo de transición y ajustes | 15d | 2021-06-01 11:00 | 2021-06-22 11:00 | 75 | 0d |  |
